Schedule from MS Project, 2023-04-03 to 2023-12-13.
Microsoft

## Calendars

- Стандартный: Mon-Fri 09:00-13:00, 14:00-18:00; Sat-Sun off.

## Schedule

| ID | WBS | Task | Type | Duration | Start | Finish | Predecessors | Total slack | Free slack | Constraint |
| --- | --- | --- | --- | --- | --- | --- | --- | --- | --- | --- |
| 1 | 1 | Разработка проектной документации |  | 1d? | 2023-04-03 | 2023-04-03 |  | 182d |  |  |
| 2 | 2 | Архитектурно-строительные решения* | manual | 12d | 2023-04-15 | 2023-05-01 |  |  |  |  |
| 3 | 3 | Согласование | manual | 10d | 2023-05-02 | 2023-05-15 | 2 |  |  |  |
| 4 | 4 | Водоснабжение, канализация, тепломеханические решения* | manual | 12d | 2023-04-15 | 2023-05-01 |  |  |  |  |
| 5 | 5 | Согласование | manual | 10d | 2023-05-02 | 2023-05-15 | 4 |  |  |  |
| 6 | 6 | Внутренний противопожарный водопровод* | manual | 12d | 2023-04-15 | 2023-05-01 |  |  |  |  |
| 7 | 7 | Согласование | manual | 10d | 2023-05-02 | 2023-05-15 | 6 |  |  |  |
| 8 | 8 | Отопление, вентиляция и кондиционирование* | manual | 12d | 2023-04-15 | 2023-05-01 |  |  |  |  |
| 9 | 9 | Согласование | manual | 10d | 2023-05-02 | 2023-05-15 | 8 |  |  |  |
| 10 | 10 | Электротехнические решения* | manual | 12d | 2023-04-15 | 2023-05-01 |  |  |  |  |
| 11 | 11 | Согласование | manual | 10d | 2023-05-02 | 2023-05-15 | 10 |  |  |  |
| 12 | 12 | Слаботочные системы* | manual | 12d | 2023-04-15 | 2023-05-01 |  |  |  |  |
| 13 | 13 | Согласование | manual | 10d | 2023-05-02 | 2023-05-15 | 12 |  |  |  |
| 14 | 14 | Сметная документация* | manual | 16d | 2023-05-01 | 2023-05-20 |  |  |  |  |
| 15 | 15 | Согласование | manual | 10d | 2023-05-22 | 2023-06-02 | 14 |  |  |  |
| 16 | 16 | **Тендерные процедуры** |  | 0d | 2023-04-07 | 2023-04-07 |  | 23d |  |  |
| 17 | 16.1 | Выбор подрядчика | milestone | 0d | 2023-04-07 | 2023-04-07 |  | 23d | 0d | start no earlier than 2023-04-07 |
| 18 | 16.2 | Заключение договора | milestone | 0d | 2023-04-07 | 2023-04-07 | 17 | 23d | 0d |  |
| 19 | 16.3 | Получение БГ | milestone | 0d | 2023-04-07 | 2023-04-07 | 18 | 23d | 0d |  |
| 20 | 16.4 | Авансовый платеж | milestone | 0d | 2023-04-07 | 2023-04-07 | 19 | 23d | 0d |  |
| 21 | 17 | **Поставка оборудования и материалов** |  | 120d | 2023-05-10 | 2023-10-24 |  | 0d |  |  |
| 22 | 17.1 | Изготовление поставка компрессоров |  | 120d | 2023-05-10 | 2023-10-24 | 20 | 0d |  | start no earlier than 2023-05-10 |
| 23 | 17.2 | Изготовление и поставка вент. Оборудования |  | 75d | 2023-05-10 | 2023-08-22 |  | 51d | 0d | start no earlier than 2023-05-10 |
| 24 | 17.3 | Поставка шинопровода |  | 60d | 2023-05-10 | 2023-08-01 | 20 | 96d |  | start no earlier than 2023-05-10 |
| 25 | 17.4 | Автоматичские ворота |  | 45d | 2023-05-10 | 2023-07-11 |  | 111d |  | start no earlier than 2023-05-10 |
| 26 | 17.5 | Распред шкафы (сборные) |  | 30d | 2023-05-10 | 2023-06-20 | 20 | 66d | 16d | start no earlier than 2023-05-10 |
| 27 | 17.6 | Поставка РШП |  | 30d | 2023-05-10 | 2023-06-20 | 20 | 66d | 16d | start no earlier than 2023-05-10 |

| ID | WBS | Task | Type | Duration | Start | Finish | Predecessors | Total slack | Free slack | Constraint |
| --- | --- | --- | --- | --- | --- | --- | --- | --- | --- | --- |
| 28 | 18 | **АРХИТЕКТУРНО СТРОИТЕЛЬНЫЕ РЕШЕНИЯ** |  | 158d | 2023-04-07 | 2023-11-14 |  | 21d |  |  |
| 29 | 18.1 | Начало работ АР | milestone | 0d | 2023-04-07 | 2023-04-07 | 20 | 179d |  |  |
| 30 | 18.2 | ЖД пути цеха №8 |  | 90d | 2023-05-10 | 2023-09-12 |  | 21d | 0d | start no earlier than 2023-05-10 |
| 31 | 18.3 | Перегородка цеха №8 |  | 60d | 2023-06-05 | 2023-08-25 |  | 33d | 0d | start no earlier than 2023-06-05 |
| 32 | 18.4 | Ворота, двери перегородки цеха |  | 30d | 2023-08-28 | 2023-10-06 | 31 | 33d | 0d |  |
| 33 | 18.5 | Ворота цеха автоматические вьездные 4 шт |  | 30d | 2023-08-28 | 2023-10-06 | 32SS | 33d | 0d |  |
| 34 | 18.6 | Устройство полов 8000 м2 (огнестойкие и повышенного износа) |  | 45d | 2023-09-13 | 2023-11-14 | 30 | 21d |  |  |
| 35 | 19 | **АБК** |  | 100d | 2023-06-20 | 2023-11-07 |  | 26d |  |  |
| 36 | 19.1 | Начало работ АБК | milestone | 0d | 2023-06-20 | 2023-06-20 | 30SS+30d | 26d | 0d |  |
| 37 | 19.2 | Полы, отделка полов |  | 90d | 2023-06-21 | 2023-10-24 | 36 | 36d |  |  |
| 38 | 19.3 | Перегородки, отделка |  | 60d | 2023-06-21 | 2023-09-12 | 36 | 26d | 0d |  |
| 39 | 19.4 | Подвесные потолки |  | 15d | 2023-09-13 | 2023-10-03 | 38 | 51d |  |  |
| 40 | 19.5 | Двери, окна |  | 30d | 2023-09-13 | 2023-10-24 | 38 | 36d |  |  |
| 41 | 19.6 | Устройство отделка мокрых зон |  | 30d | 2023-09-13 | 2023-10-24 | 42 | 36d |  |  |
| 42 | 19.7 | Водопровод, канализация |  | 60d | 2023-06-21 | 2023-09-12 | 36 | 36d | 0d |  |
| 43 | 19.8 | Освещение, электропитание |  | 70d | 2023-08-02 | 2023-11-07 | 38SS+30d | 26d | 0d |  |
| 44 | 19.9 | Отопление |  | 60d | 2023-06-21 | 2023-09-12 | 42SS | 66d |  |  |
| 45 | 20 | **ЭЛЕКТРОСНАБЖЕНИЕ** |  | 90d | 2023-06-01 | 2023-10-04 |  | 35d |  |  |
| 46 | 20.1 | Начало работ Электроснабжение | milestone | 0d | 2023-06-01 | 2023-06-01 |  | 35d | 0d | start no earlier than 2023-06-01 |
| 47 | 20.2 | Монтаж кабеля от шинопровода до сварочной розетки 380В в щитке на 31 сварочный пост |  | 60d | 2023-06-01 | 2023-08-23 | 46 | 35d | 0d |  |
| 48 | 20.3 | Монтаж кабелей питания кранов мостовых 3 шт. |  | 60d | 2023-06-01 | 2023-08-23 | 47SS | 35d | 0d |  |
| 49 | 20.4 | Монтаж распред шкафов (сборные) |  | 60d | 2023-07-13 | 2023-10-04 | 48SS+30d, 26 | 50d |  |  |
| 50 | 20.5 | Монтаж сети внутреннего освещения (общее+аварийное – светильники диодные без замены питающей сети) |  | 60d | 2023-06-01 | 2023-08-23 | 48SS | 35d | 0d |  |
| 51 | 20.6 | Монтаж светильников уличные наружного освещения |  | 30d | 2023-08-24 | 2023-10-04 | 50 | 50d |  |  |
| 52 | 20.7 | Монтаж шинопровода |  | 60d | 2023-07-13 | 2023-10-04 | 48SS+30d, 27 | 50d |  |  |

| ID | WBS | Task | Type | Duration | Start | Finish | Predecessors | Total slack | Free slack | Constraint |
| --- | --- | --- | --- | --- | --- | --- | --- | --- | --- | --- |
| 53 | 21 | **ОТОПЛЕНИЕ И ВЕНТИЛЯЦИЯ** |  | 105d | 2023-06-05 | 2023-10-27 |  | 33d |  |  |
| 54 | 21.1 | Начало работ по отплению и вентиляции | milestone | 0d | 2023-06-05 | 2023-06-05 |  | 68d | 0d | start no earlier than 2023-06-05 |
| 55 | 21.2 | Монтаж системы приточно-вытяжной вентиляции |  | 40d | 2023-06-05 | 2023-07-28 | 54 | 68d | 17d |  |
| 56 | 21.3 | Монтаж приточно-вытяжной установки и ситемы фильтрации |  | 15d | 2023-08-23 | 2023-09-12 | 55, 23 | 51d | 0d |  |
| 57 | 21.4 | Монтаж водяных тепловых завес над воротами |  | 15d | 2023-10-09 | 2023-10-27 | 33SS+30d | 33d |  |  |
| 58 | 21.5 | Установка кондиционеров для АБК |  | 30d | 2023-09-13 | 2023-10-24 | 43SS+30d | 36d |  |  |
| 59 | 21.6 | Пусконаладочные работы |  | 15d | 2023-09-13 | 2023-10-03 | 56 | 51d |  |  |
| 60 | 22 | **СИСТЕМА ПОДАЧИ СЖАТОГО ВОЗДУХА** |  | 140d | 2023-06-01 | 2023-12-13 |  | 0d |  |  |
| 61 | 22.1 | Подготовительные работы |  | 7d | 2023-06-01 | 2023-06-09 |  | 103d | 0d | start no earlier than 2023-06-01 |
| 62 | 22.2 | Дополнительные трубопроводы для подачи воздуха |  | 30d | 2023-06-12 | 2023-07-21 | 61 | 103d |  |  |
| 63 | 22.3 | Монтаж компрессоров |  | 21d | 2023-10-25 | 2023-11-22 | 22 | 0d |  |  |
| 64 | 22.4 | Пусконаладка |  | 15d | 2023-11-23 | 2023-12-13 | 63 | 0d |  |  |
| 65 | 23 | **АПС пожарная сигнализация** |  | 45d | 2023-09-01 | 2023-11-02 |  | 0d |  |  |
| 66 | 23.1 | Начало работ ПЖ | milestone, manual | 0d | 2023-09-01 | 2023-09-01 | 50 |  |  |  |
| 67 | 23.2 | - пульт АПС С200-М |  | 45d | 2023-09-01 | 2023-11-02 | 66 | 29d |  |  |
| 68 | 23.3 | - извещатели пожарные автоматические и ручные |  | 45d | 2023-09-01 | 2023-11-02 | 66 | 29d |  |  |
| 69 | 23.4 | - ИБП |  | 45d | 2023-09-01 | 2023-11-02 | 66 | 29d |  |  |
| 70 | 24 | **СОУЭ (оповещение и эвакуация)** |  | 45d | 2023-09-01 | 2023-11-02 |  | 0d |  |  |
| 71 | 24.1 | Начало работ СОУЭ | milestone, manual | 0d | 2023-09-01 | 2023-09-01 | 50 |  |  |  |
| 72 | 24.2 | - звуковые оповещатели |  | 45d | 2023-09-01 | 2023-11-02 | 71 | 29d |  |  |
| 73 | 24.3 | - световые оповещатели |  | 45d | 2023-09-01 | 2023-11-02 | 71 | 29d |  |  |
| 74 | 25 | **СКС** |  | 45d | 2023-09-01 | 2023-11-02 |  | 0d |  |  |
| 75 | 25.1 | Начало работ СКС | milestone, manual | 0d | 2023-09-01 | 2023-09-01 | 50 |  |  |  |
| 76 | 25.2 | - ВОЛС кабель |  | 45d | 2023-09-01 | 2023-11-02 | 75 | 29d |  |  |
| 77 | 25.3 | - медный кабель (витая пара) |  | 45d | 2023-09-01 | 2023-11-02 | 75 | 29d |  |  |
| 78 | 25.4 | - патч корды |  | 45d | 2023-09-01 | 2023-11-02 | 75 | 29d |  |  |
| 79 | 25.5 | - оптические кроссы |  | 45d | 2023-09-01 | 2023-11-02 | 75 | 29d |  |  |
| 80 | 25.6 | - патч панели |  | 45d | 2023-09-01 | 2023-11-02 | 75 | 29d |  |  |
| 81 | 25.7 | - Ethernet коммутаторы |  | 45d | 2023-09-01 | 2023-11-02 | 75 | 29d |  |  |
| 82 | 25.8 | - ИБП |  | 45d | 2023-09-01 | 2023-11-02 | 75 | 29d |  |  |
| 83 | 25.9 | - кабельные органайзеры |  | 45d | 2023-09-01 | 2023-11-02 | 75 | 29d |  |  |
| 84 | 25.10 | - универсальные розетки типа RJ45 |  | 45d | 2023-09-01 | 2023-11-02 | 75 | 29d |  |  |
| 85 | 25.11 | - кабельные лотки |  | 45d | 2023-09-01 | 2023-11-02 | 75 | 29d |  |  |

| ID | WBS | Task | Type | Duration | Start | Finish | Predecessors | Total slack | Free slack |
| --- | --- | --- | --- | --- | --- | --- | --- | --- | --- |
| 86 | 26 | **СОТ (охранное телевидение)** |  | 45d | 2023-09-01 | 2023-11-02 |  | 0d |  |
| 87 | 26.1 | Начало работ СОТ | manual | 1d? | 2023-09-01 | 2023-09-01 |  |  |  |
| 88 | 26.2 | - IP-камеры Hikvision с поддержкой РоЕ |  | 45d | 2023-09-01 | 2023-11-02 | 75 | 29d |  |
| 89 | 26.3 | - розетки, репитеры, кабель |  | 45d | 2023-09-01 | 2023-11-02 | 75 | 29d | 0d |
| 90 | 26.4 | - коммутаторы |  | 45d | 2023-09-01 | 2023-11-02 | 89SS | 29d |  |
